# Office Remodel 3-2

Schedule from MS Project, 2015-10-05 to 2015-11-11, costs in $.
P8 LLC

## Calendars

- Standard: Mon-Fri 08:00-12:00, 13:00-17:00; Sat-Sun off.
- Evening Drywall Install: Mon-Fri 16:00-24:00; Sat-Sun off.

## Resources

| Resource | Rate |
| --- | --- |
| Toby Nixon | 12.5 |
| Lori Kane | 12.5 |
| Run Liu | 20 |
| electrician | 30 |
| plumber | 30 |
| drywall | 11 |
| nails | 5 |
| John Emory | 11.25 |
| scaffolding | 6.25 |
| table saw | 4.38 |
| painter | 25 |

## Schedule

| ID | WBS | Task | Duration | Start | Finish | Predecessors | Total slack | Free slack | Calendar | Resources | Work | Cost |
| --- | --- | --- | --- | --- | --- | --- | --- | --- | --- | --- | --- | --- |
| 1 | 1 | **Prep** | 0.5d | 2015-10-05 | 2015-10-05 |  | 0.38d |  |  |  | 16h | 370 |
| 2 | 1.1 | Remove existing furniture | 0.5d | 2015-10-05 | 2015-10-05 |  | 0.38d | 0d |  | Run Liu | 4h | 80 |
| 3 | 1.2 | Remove existing appliances | 0.5d | 2015-10-05 | 2015-10-05 |  | 0.38d | 0d |  | electrician; Lori Kane; plumber | 12h | 290 |
| 4 | 2 | **Demolition** | 5d | 2015-10-05 | 2015-10-12 |  | 0.38d |  |  |  | 80h | 950 |
| 5 | 2.1 | Remove existing ceiling | 1d | 2015-10-05 | 2015-10-06 | 2, 3 | 0.38d | 0d |  | Toby Nixon; John Emory | 16h | 190 |
| 6 | 2.2 | Tear out inside dividing walls | 2d | 2015-10-06 | 2015-10-08 | 5 | 0.38d | 0d |  | John Emory; Toby Nixon | 32h | 380 |
| 7 | 2.3 | Remove drywall from main walls | 2d | 2015-10-08 | 2015-10-12 | 6 | 0.38d | 0d |  | John Emory; Toby Nixon | 32h | 380 |
| 8 | 3 | **Construction** | 12.5d | 2015-10-12 | 2015-10-28 |  | 0d |  |  |  | 176h | 3,215 |
| 9 | 3.1 | Install interior stud walls | 3d | 2015-10-12 | 2015-10-15 | 7 | 0.38d | 0d |  | John Emory; Toby Nixon | 48h | 570 |
| 10 | 3.2 | Re-run electrical in all stud walls | 1d | 2015-10-15 | 2015-10-16 | 9 | 0.38d |  |  | electrician | 8h | 240 |
| 11 | 3.3 | Re-run plumbing for sink and icemaker | 1d | 2015-10-15 | 2015-10-16 | 9 | 0.38d |  |  | plumber | 8h | 240 |
| 12 | 3.4 | Install drywall | 5d | 2015-10-16 | 2015-10-23 | 10, 11 | 0d |  | Evening Drywall Install | drywall [5000%]; nails [500%]; John Emory; Toby Nixon | 80h | 1,525 |
| 13 | 3.5 | Install ceiling grid | 3d | 2015-10-23 | 2015-10-27 | 12 | 0d |  |  | Run Liu | 24h | 480 |
| 14 | 3.6 | Install ceiling tile | 1d | 2015-10-28 | 2015-10-28 | 13 | 0d |  |  | Run Liu | 8h | 160 |
| 15 | 4 | **Finishing Work** | 9.5d | 2015-10-29 | 2015-11-11 |  | 0d |  |  |  | 124h | 2,180 |
| 16 | 4.1 | Paint walls and woodwork | 4d | 2015-10-29 | 2015-11-03 | 14 | 0d |  |  | Run Liu [50%]; Toby Nixon [50%]; Lori Kane [50%]; painter [50%] | 64h | 1,120 |
| 17 | 4.2 | Install new floor tile | 3d | 2015-11-04 | 2015-11-06 | 16 | 0d |  |  | John Emory | 24h | 270 |
| 18 | 4.3 | Re-install appliances | 1d | 2015-11-09 | 2015-11-09 | 17 | 0d |  |  | electrician; plumber; Run Liu | 24h | 640 |
| 19 | 4.4 | Final cleaning | 1d | 2015-11-10 | 2015-11-10 | 18 | 0d |  |  | Lori Kane | 8h | 100 |
| 20 | 4.5 | Re-install furniture | 0.5d | 2015-11-11 | 2015-11-11 | 19 | 0d |  |  | Lori Kane | 4h | 50 |
